# MOVIMIENTO DE TIERRAS III PARTE - CUENCA CAÑETE

Schedule from Primavera P6, 2023-10-02 to 2024-10-30, data date 2023-10-01.

## Calendars

- 2T - 6x1 - 8 hr - Cañete III: Mon-Sat 02:00-06:00, 08:00-12:00, 14:00-18:00, 20:00-00:00; Sun off. Exceptions (off unless hours are given): 2023-11-01, 2023-12-08, 2023-12-25, 2024-01-01, 2024-03-28 to 2024-03-29, 2024-05-01, 2024-06-07, 2024-06-29, 2024-07-29, 2024-08-06, 2024-08-30, 2024-10-08.
- 2T - 6x1 - 8 hr - Cañete - paro en avenidas: Mon-Sat 02:00-06:00, 08:00-12:00, 14:00-18:00, 20:00-00:00; Sun off. Exceptions (off unless hours are given): 2023-11-01, 2023-12-08, 2023-12-16, 2023-12-18 to 2023-12-23, 2023-12-25 to 2023-12-30, 2024-01-01 to 2024-01-06, 2024-01-08 to 2024-01-13, 2024-01-15 to 2024-01-20, 2024-01-22 to 2024-01-27, 2024-01-29 to 2024-02-03, 2024-02-05 to 2024-02-10, 2024-02-12 to 2024-02-17, 2024-02-19 to 2024-02-24, 2024-02-26 to 2024-03-02, 2024-03-04 to 2024-03-09, 2024-03-11 to 2024-03-16, 2024-03-18 to 2024-03-23, 2024-03-25 to 2024-03-30, 2024-04-01 to 2024-04-06, 2024-04-08 to 2024-04-13, 2024-04-15, 2024-05-01, 2024-06-07, 2024-06-29, 2024-07-29, 2024-08-06, 2024-08-30, 2024-10-08.

## Schedule

| ID | WBS | Activity | Type | Duration | Start | Finish | Predecessors | Total float | Free float | Calendar | Filtro |
| --- | --- | --- | --- | --- | --- | --- | --- | --- | --- | --- | --- |
|  | 1 | **Hitos** |  |  | 2023-10-02 | 2024-10-23 |  |  |  |  |  |
| A1000 |  | Inicio de obra - Acceso al Sitio | milestone | 0d | 2023-10-02 | 2023-10-02 |  | 0d |  |  |  |
| A1010 |  | Inicio de Habilitación y mejoramiento de accesos | milestone | 0d | 2023-10-16 | 2023-10-16 | A1150 SS+9d, A1120 SS+6d, A1050 SS | 13d | 0d |  |  |
| A1020 |  | Inicio de Mov. Tierras _ Diques Paquete 4 | milestone | 0d | 2023-11-02 | 2023-11-02 | A18930 SS+26d, A1050 | 0d |  |  |  |
| A1030 |  | Culminación de obras_ Diques Paquete 4 | milestone | 0d | 2024-10-23 | 2024-10-23 | A1160, A7980, A6400, A7970, A14630, A14640, A14670, A19135, A1080, A19890, A5890, A20020, A1040, A1130, A3530, A3540, A3570, A4120, A8710, A8720 | 0d |  |  |  |
|  | 2 | **Obras Provisionales** |  |  | 2023-10-02 | 2024-10-30 |  |  |  |  |  |
| A1050 |  | Movilización de maquinaria pesada |  | 26d | 2023-10-02 | 2023-11-01 | A1000 | 0d |  |  |  |
| A1120 |  | Cruce provisional de rio |  | 26d | 2023-10-09 | 2023-11-09 | A1150 SS+3d | 13d | 0d | 2T - 6x1 - 8 hr - Cañete - paro en avenidas |  |
| A1060 |  | Mejoramiento y Habilitación de caminos de acceso |  | 300d | 2023-10-16 | 2024-10-15 | A1010 | 13d | 0d |  |  |
| A1070 |  | Limpieza manual de material vegetal y de residuos |  | 2.5d | 2023-10-16 | 2023-10-18 | A1060 SS | 255.5d | 9.5d |  |  |
| A1090 |  | Habilitación de plataformas |  | 5d | 2023-10-16 | 2023-10-21 | A1010 | 292d | 0d |  |  |
| A1040 |  | Campamento Provisional de Obra |  | 12d | 2023-10-19 | 2023-11-03 | A1090 SS+3d | 292d |  |  |  |
| A1100 |  | Tubería HDPE Corrugada Ø=600mm, para caminos de acceso (o similar) |  | 32d | 2023-10-30 | 2023-12-07 | A1060 SS+12d, A1070 | 246d | 0d |  |  |
| A1110 |  | Tubería HDPE Corrugada Ø=1000mm, para caminos de acceso (o similar) |  | 32d | 2023-10-30 | 2023-12-07 | A1100 SS | 246d |  |  |  |
| A1080 |  | Mantenimiento de caminos de acceso |  | 288d | 2023-11-06 | 2024-10-20 | A1150 | 2d |  |  |  |
| A1140 |  | Desmovilización de maquinaria pesada |  | 26d | 2024-09-28 | 2024-10-30 | A1030 FF+6d | 0d |  |  |  |
| A1130 |  | Demolición de cruce provisional |  | 17d | 2024-10-02 | 2024-10-23 | A1120, A14540, A3610, A1110 | 0d |  |  |  |
|  | 3 | **Topografía** |  |  | 2023-10-05 | 2024-10-19 |  |  |  |  |  |
| A1150 |  | Trazo y replanteo inicial |  | 26d | 2023-10-05 | 2023-11-05 | A1050 SS+3d | 2d | 0d |  |  |
| A1160 |  | Trazo y replanteo durante la obra |  | 287d | 2023-11-06 | 2024-10-19 | A1150 | 3d |  |  |  |
|  | 4 | **Diques** |  |  | 2023-11-02 | 2024-10-23 |  |  |  |  |  |
|  | 18 | **DC-PR-01A-D** |  |  | 2023-11-02 | 2023-11-11 |  |  |  |  |  |
|  | 1 | **Excavaciones** |  |  | 2023-11-02 | 2023-11-11 |  |  |  |  |  |
| A13870 |  | Descolmatación |  | 8d | 2023-11-02 | 2023-11-11 | A1020 | 0d |  | 2T - 6x1 - 8 hr - Cañete - paro en avenidas | grupo 1 |

| ID | WBS | Activity | Duration | Start | Finish | Predecessors | Total float | Free float | Calendar | Filtro |
| --- | --- | --- | --- | --- | --- | --- | --- | --- | --- | --- |
|  | 17 | **ENR-PTE-42-39** |  | 2023-11-11 | 2023-11-23 |  |  |  |  |  |
|  | 1 | **Excavaciones** |  | 2023-11-11 | 2023-11-14 |  |  |  |  |  |
| A13020 |  | Desbroce | 2d | 2023-11-11 | 2023-11-14 | A13870 | 0d |  | 2T - 6x1 - 8 hr - Cañete - paro en avenidas | grupo 1 |
| A13040 |  | Excavación de cimentación | 2d | 2023-11-11 | 2023-11-14 | A13020 SS | 19d | 0d | 2T - 6x1 - 8 hr - Cañete - paro en avenidas | grupo 1 |
|  | 4 | **Colocación de Roca** |  | 2023-11-14 | 2023-11-23 |  |  |  |  |  |
| A13270 |  | Enrocado talud encachado con concreto | 8d | 2023-11-14 | 2023-11-23 | A13040 | 19d |  | 2T - 6x1 - 8 hr - Cañete - paro en avenidas | grupo 1 |
|  | 7 | **DE-PR-22-D** |  | 2023-11-14 | 2024-08-16 |  |  |  |  |  |
|  | 1 | **Época Estiaje 2023** |  | 2023-11-14 | 2023-12-15 |  |  |  |  |  |
|  | 1 | **Excavaciones** |  | 2023-11-14 | 2023-12-15 |  |  |  |  |  |
| A5620 |  | Desbroce | 25d | 2023-11-14 | 2023-12-14 | A13020 | 0d |  | 2T - 6x1 - 8 hr - Cañete - paro en avenidas | grupo 1 |
| A5630 |  | Remoción de dique existente | 25d | 2023-11-14 | 2023-12-14 | A5620 SS | 0d |  | 2T - 6x1 - 8 hr - Cañete - paro en avenidas | grupo 1 |
| A5640 |  | Excavación de cimentación | 25d | 2023-11-14 | 2023-12-14 | A5630 SS | 0d |  | 2T - 6x1 - 8 hr - Cañete - paro en avenidas | grupo 1 |
| A5645 |  | Excavación localizada - Sobreexcavación | 25d | 2023-11-14 | 2023-12-14 | A5640 SS | 2d | 0d | 2T - 6x1 - 8 hr - Cañete - paro en avenidas | grupo 1 |
| A5660 |  | Excavación de uña | 10d | 2023-11-17 | 2023-11-29 | A5630 SS+3d | 22d | 14d | 2T - 6x1 - 8 hr - Cañete - paro en avenidas | grupo 1 |
| A5650 |  | Perfilado y conformación de plataforma de fundación | 20d | 2023-11-21 | 2023-12-15 | A5640 SS+6d | 1d | 0d | 2T - 6x1 - 8 hr - Cañete - paro en avenidas | grupo 1 |
|  | 2 | **Rellenos** |  | 2023-11-28 | 2023-12-15 |  |  |  |  |  |
| A5740 |  | Relleno con material granular | 14d | 2023-11-28 | 2023-12-15 | A5650 SS+6d | 1d | 0d | 2T - 6x1 - 8 hr - Cañete - paro en avenidas | grupo 1 |
| A5745 |  | Relleno con material seleccionado | 14d | 2023-11-28 | 2023-12-15 | A5740 SS | 1d | 0d | 2T - 6x1 - 8 hr - Cañete - paro en avenidas | grupo 1 |
| A5746 |  | Perfilado de talud del dique | 8d | 2023-12-05 | 2023-12-15 | A5745 SS+6d | 1d | 0d | 2T - 6x1 - 8 hr - Cañete - paro en avenidas | grupo 1 |
|  | 3 | **Geotextil** |  | 2023-12-13 | 2023-12-15 |  |  |  |  |  |
| A5800 |  | Instalación de Geotextil 400 gr/m2 | 2d | 2023-12-13 | 2023-12-15 | A5810 SS | 1d |  | 2T - 6x1 - 8 hr - Cañete - paro en avenidas | grupo 1 |
| A5810 |  | Zanja de anclaje | 2d | 2023-12-13 | 2023-12-15 | A5746 SS+6d | 1d | 0d | 2T - 6x1 - 8 hr - Cañete - paro en avenidas | grupo 1 |
|  | 2 | **Época Estiaje 2024** |  | 2024-05-28 | 2024-08-16 |  |  |  |  |  |
|  | 2 | **Rellenos** |  | 2024-05-28 | 2024-08-16 |  |  |  |  |  |
| A19760 |  | Relleno con material granular | 18d | 2024-05-28 | 2024-06-19 | A6480 | 14d | 0d | 2T - 6x1 - 8 hr - Cañete - paro en avenidas | grupo 1 |
| A19765 |  | Relleno con material seleccionado | 18d | 2024-05-28 | 2024-06-19 | A19760 SS, A6485 | 14d | 0d | 2T - 6x1 - 8 hr - Cañete - paro en avenidas | grupo 1 |
| A19766 |  | Perfilado de talud del dique | 18d | 2024-05-29 | 2024-06-20 | A19765 SS+1d, A6486 | 14d | 5d | 2T - 6x1 - 8 hr - Cañete - paro en avenidas | grupo 1 |
| A19810 |  | Grava para drenaje | 11d | 2024-06-19 | 2024-07-03 | A19765, A6495 | 74d | 35d | 2T - 6x1 - 8 hr - Cañete - paro en avenidas | grupo 1 |
| A19770 |  | Relleno sin compactar | 6d | 2024-08-09 | 2024-08-16 | A19850 FF+3d, A19840, A6490 | 44d | 30d | 2T - 6x1 - 8 hr - Cañete - paro en avenidas | grupo 1 |
| A19780 |  | Relleno afirmado | 2.5d | 2024-08-13 | 2024-08-15 | A19850, A6500 | 51.5d | 39.5d | 2T - 6x1 - 8 hr - Cañete - paro en avenidas | grupo 1 |

| ID | WBS | Activity | Duration | Start | Finish | Predecessors | Total float | Free float | Calendar | Filtro |
| --- | --- | --- | --- | --- | --- | --- | --- | --- | --- | --- |
|  | 3 | **Geotextil** |  | 2024-06-12 | 2024-07-06 |  |  |  |  |  |
| A19820 |  | Instalación de Geotextil 400 gr/m2 | 20d | 2024-06-12 | 2024-07-06 | A19830 SS, A6540 | 9d | 1d | 2T - 6x1 - 8 hr - Cañete - paro en avenidas | grupo 1 |
| A19830 |  | Zanja de anclaje | 20d | 2024-06-12 | 2024-07-06 | A19766 SS+6d, A6550 | 9d | 0d | 2T - 6x1 - 8 hr - Cañete - paro en avenidas | grupo 1 |
|  | 4 | **Colocación de Roca** |  | 2024-06-21 | 2024-08-13 |  |  |  |  |  |
| A19840 |  | Colocación de roca en uña | 22d | 2024-06-21 | 2024-07-18 | A19820 SS+3d, A6560 | 4d | 0d | 2T - 6x1 - 8 hr - Cañete - paro en avenidas | grupo 1 |
| A19850 |  | Colocación de roca en talud | 32d | 2024-07-04 | 2024-08-13 | A19840 SS+6d, A6570 | 0d |  | 2T - 6x1 - 8 hr - Cañete - paro en avenidas | grupo 1 |
|  | 1 | **DE-PR-08-I** |  | 2023-12-14 | 2024-03-09 |  |  |  |  |  |
|  | 1 | **Excavaciones** |  | 2023-12-14 | 2024-01-05 |  |  |  |  |  |
| A1180 |  | Desbroce | 16d | 2023-12-14 | 2024-01-04 | A5620 | 0d |  |  | grupo 1 |
| A1190 |  | Remoción de dique existente | 16d | 2023-12-14 | 2024-01-04 | A1180 SS, A5630 | 0d |  |  | grupo 1 |
| A1200 |  | Excavación de cimentación | 16d | 2023-12-14 | 2024-01-04 | A1190 SS, A5640 | 0d |  |  | grupo 1 |
| A1205 |  | Excavación localizada - Sobreexcavación | 16d | 2023-12-14 | 2024-01-04 | A1200 SS, A5645 | 15d | 0d |  | grupo 1 |
| A1220 |  | Excavación de uña | 11d | 2023-12-18 | 2023-12-31 | A1190 SS+3d, A5660 | 107d | 5d |  | grupo 1 |
| A1210 |  | Perfilado y conformación de plataforma de fundación | 11d | 2023-12-21 | 2024-01-05 | A1200 SS+6d, A5650 | 0d |  |  | grupo 1 |
|  | 2 | **Rellenos** |  | 2023-12-29 | 2024-02-29 |  |  |  |  |  |
| A1300 |  | Relleno con material granular | 29d | 2023-12-29 | 2024-02-02 | A1210 SS+6d, A5740 | 0d |  |  | grupo 1 |
| A1305 |  | Relleno con material seleccionado | 29d | 2023-12-29 | 2024-02-02 | A1300 SS, A5745 | 5d | 0d |  | grupo 1 |
| A1306 |  | Perfilado de talud del dique | 25d | 2024-01-06 | 2024-02-04 | A1305 SS+6d, A5746 | 5d | 0d |  | grupo 1 |
| A1350 |  | Grava para drenaje | 14d | 2024-02-02 | 2024-02-18 | A1305 | 112d | 9d |  | grupo 1 |
| A1310 |  | Relleno sin compactar | 7d | 2024-02-21 | 2024-02-29 | A1390, A1380 | 137d | 4d |  | grupo 1 |
| A1320 |  | Relleno afirmado | 2.5d | 2024-02-21 | 2024-02-23 | A1390 | 174.5d | 8.5d |  | grupo 1 |
|  | 3 | **Geotextil** |  | 2024-01-10 | 2024-02-06 |  |  |  |  |  |
| A1360 |  | Instalación de Geotextil 400 gr/m2 | 23d | 2024-01-10 | 2024-02-06 | A1370 SS, A5800 | 5d | 0d |  | grupo 1 |
| A1370 |  | Zanja de anclaje | 23d | 2024-01-10 | 2024-02-06 | A1306 SS+3d, A5810 | 5d | 0d |  | grupo 1 |

| ID | WBS | Activity | Duration | Start | Finish | Predecessors | Total float | Free float | Filtro |
| --- | --- | --- | --- | --- | --- | --- | --- | --- | --- |
|  | 4 | **Colocación de Roca** |  | 2024-01-13 | 2024-02-21 |  |  |  |  |
| A1380 |  | Colocación de roca en uña | 25d | 2024-01-13 | 2024-02-11 | A1360 SS+3d, A13270 | 5d | 0d | grupo 1 |
| A1390 |  | Colocación de roca en talud | 27d | 2024-01-20 | 2024-02-21 | A1380 SS+6d | 10d | 0d | grupo 1 |
|  | 6 | **Accesos** |  | 2024-02-21 | 2024-03-09 |  |  |  |  |
| A1880 |  | Encofrado y desencofrado pavimento rígido e=0.15m | 10d | 2024-02-21 | 2024-03-03 | A1390 | 169d | 0d | grupo 1 |
| A1870 |  | Concreto clase C (f'c=280 kg/cm2) en losa | 2.5d | 2024-03-04 | 2024-03-06 | A1880 | 178.5d | 0d | grupo 1 |
| A1890 |  | Junta en Pavimentos con Pasadores | 2.5d | 2024-03-04 | 2024-03-06 | A1870 SS | 178.5d | 0d | grupo 1 |
| A1900 |  | Concreto Ciclopeo f'c=210 kg/cm2 + 30% PM | 2.5d | 2024-03-06 | 2024-03-09 | A1870, A1890 | 178.5d | 61d | grupo 1 |
|  | 2 | **DE-PR-09-I** |  | 2024-01-04 | 2024-03-08 |  |  |  |  |
|  | 1 | **Excavaciones** |  | 2024-01-04 | 2024-01-16 |  |  |  |  |
| A1920 |  | Desbroce | 4d | 2024-01-04 | 2024-01-09 | A1180 | 15d | 0d | grupo 1 |
| A1930 |  | Remoción de dique existente | 4d | 2024-01-04 | 2024-01-09 | A1920 SS, A1190 | 15d | 0d | grupo 1 |
| A1940 |  | Excavación de cimentación | 4d | 2024-01-04 | 2024-01-09 | A1930 SS, A1200 | 15d | 0d | grupo 1 |
| A1945 |  | Excavación localizada - Sobreexcavación | 4d | 2024-01-04 | 2024-01-09 | A1940 SS, A1205 | 15d | 0d | grupo 1 |
| A1960 |  | Excavación de uña | 7d | 2024-01-08 | 2024-01-16 | A1930 SS+3d, A1220 | 102d | 0d | grupo 1 |
| A1950 |  | Perfilado y conformación de plataforma de fundación | 5d | 2024-01-09 | 2024-01-14 | A1945, A1210 | 15d | 1d | grupo 1 |
|  | 2 | **Rellenos** |  | 2024-02-02 | 2024-03-08 |  |  |  |  |
| A2040 |  | Relleno con material granular | 6d | 2024-02-02 | 2024-02-09 | A1950 SS+6d, A1300 | 0d |  | grupo 1 |
| A2045 |  | Perfilado de talud del dique | 3d | 2024-02-09 | 2024-02-13 | A1306, A2040 | 1d | 0d | grupo 1 |
| A2050 |  | Relleno sin compactar | 3d | 2024-03-05 | 2024-03-08 | A2130, A2120, A1310 | 133d | 16d | grupo 1 |
| A2060 |  | Relleno afirmado | 2d | 2024-03-05 | 2024-03-07 | A2130, A1320 | 166d | 17d | grupo 1 |
|  | 3 | **Geotextil** |  | 2024-02-13 | 2024-02-27 |  |  |  |  |
| A2100 |  | Instalación de Geotextil 400 gr/m2 | 12d | 2024-02-13 | 2024-02-27 | A2110 SS, A1360 | 1d | 0d | grupo 1 |
| A2110 |  | Zanja de anclaje | 12d | 2024-02-13 | 2024-02-27 | A2045, A1370 | 1d | 0d | grupo 1 |

| ID | WBS | Activity | Duration | Start | Finish | Predecessors | Total float | Free float | Filtro |
| --- | --- | --- | --- | --- | --- | --- | --- | --- | --- |
|  | 4 | **Colocación de Roca** |  | 2024-02-16 | 2024-03-05 |  |  |  |  |
| A2120 |  | Colocación de roca en uña | 12d | 2024-02-16 | 2024-03-01 | A2100 SS+3d, A1380 | 1d | 0d | grupo 1 |
| A2130 |  | Colocación de roca en talud | 9d | 2024-02-23 | 2024-03-05 | A2120 SS+6d, A1390 | 8d | 0d | grupo 1 |
|  | 3 | **DE-PR-10-I** |  | 2024-01-09 | 2024-04-05 |  |  |  |  |
|  | 1 | **Excavaciones** |  | 2024-01-09 | 2024-01-25 |  |  |  |  |
| A2660 |  | Desbroce | 9d | 2024-01-09 | 2024-01-19 | A1920 | 15d | 0d | grupo 1 |
| A2670 |  | Remoción de dique existente | 9d | 2024-01-09 | 2024-01-19 | A2660 SS, A1930 | 15d | 0d | grupo 1 |
| A2680 |  | Excavación de cimentación | 9d | 2024-01-09 | 2024-01-19 | A2670 SS, A1940 | 15d | 0d | grupo 1 |
| A2690 |  | Perfilado y conformación de plataforma de fundación | 7d | 2024-01-16 | 2024-01-24 | A2680 SS+6d, A1950 | 15d | 2d | grupo 1 |
| A2700 |  | Excavación de uña | 8d | 2024-01-16 | 2024-01-25 | A2670 SS+3d, A1960 | 102d | 0d | grupo 1 |
|  | 2 | **Rellenos** |  | 2024-02-09 | 2024-04-05 |  |  |  |  |
| A2780 |  | Relleno con material granular | 17d | 2024-02-09 | 2024-02-29 | A2690 SS+6d, A2040 | 0d |  | grupo 1 |
| A2785 |  | Perfilado de talud del dique | 12d | 2024-02-16 | 2024-03-01 | A2045, A2780 SS+6d | 7d | 6d | grupo 1 |
| A2830 |  | Grava para drenaje | 9d | 2024-02-29 | 2024-03-10 | A2780, A1350 | 103d | 28d | grupo 1 |
| A2790 |  | Relleno sin compactar | 6d | 2024-03-27 | 2024-04-05 | A2870, A2860, A2050 | 117d | 31d | grupo 1 |
| A2800 |  | Relleno afirmado | 2.5d | 2024-03-27 | 2024-04-01 | A2870, A2060 | 149d | 35.5d | grupo 1 |
|  | 3 | **Geotextil** |  | 2024-02-27 | 2024-03-13 |  |  |  |  |
| A2840 |  | Instalación de Geotextil 400 gr/m2 | 13d | 2024-02-27 | 2024-03-13 | A2850 SS, A2100 | 1d | 0d | grupo 1 |
| A2850 |  | Zanja de anclaje | 13d | 2024-02-27 | 2024-03-13 | A2785 SS+3d, A2110 | 1d | 0d | grupo 1 |
|  | 4 | **Colocación de Roca** |  | 2024-03-01 | 2024-03-27 |  |  |  |  |
| A2860 |  | Colocación de roca en uña | 19d | 2024-03-01 | 2024-03-23 | A2840 SS+3d, A2120 | 1d | 0d | grupo 1 |
| A2870 |  | Colocación de roca en talud | 16d | 2024-03-08 | 2024-03-27 | A2860 SS+6d, A2130 | 5d | 0d | grupo 1 |
|  | 6 | **DI-PR-21-I** |  | 2024-01-19 | 2024-05-29 |  |  |  |  |
|  | 1 | **Excavaciones** |  | 2024-01-19 | 2024-02-28 |  |  |  |  |
| A4880 |  | Desbroce | 32d | 2024-01-19 | 2024-02-25 | A2660 | 22d | 0d | grupo 1 |
| A4890 |  | Remoción de dique existente | 32d | 2024-01-19 | 2024-02-25 | A4880 SS, A2670 | 22d | 0d | grupo 1 |
| A4900 |  | Excavación de cimentación | 32d | 2024-01-19 | 2024-02-25 | A4890 SS, A2680 | 22d | 0d | grupo 1 |
| A4905 |  | Excavación localizada - Sobreexcavación | 32d | 2024-01-19 | 2024-02-25 | A4900 SS | 23d | 0d | grupo 1 |
| A4920 |  | Excavación de uña | 17d | 2024-01-25 | 2024-02-14 | A4890 SS+3d, A2700 | 102d | 13d | grupo 1 |
| A4910 |  | Perfilado y conformación de plataforma de fundación | 28d | 2024-01-26 | 2024-02-28 | A4900 SS+6d, A2690 | 23d | 4d | grupo 1 |

| ID | WBS | Activity | Duration | Start | Finish | Predecessors | Total float | Free float | Filtro |
| --- | --- | --- | --- | --- | --- | --- | --- | --- | --- |
|  | 2 | **Rellenos** |  | 2024-02-29 | 2024-05-28 |  |  |  |  |
| A5000 |  | Relleno con material granular | 37d | 2024-02-29 | 2024-04-14 | A4910 SS+6d, A2780 | 0d |  | grupo 1 |
| A5005 |  | Relleno con material seleccionado | 37d | 2024-02-29 | 2024-04-14 | A5000 SS | 0d |  | grupo 1 |
| A5006 |  | Perfilado de talud del dique | 28d | 2024-03-14 | 2024-04-18 | A5005 SS+12d, A2785 | 0d |  | grupo 1 |
| A5050 |  | Grava para drenaje | 24d | 2024-04-15 | 2024-05-14 | A5005, A2830 | 75d | 0d | grupo 1 |
| A5010 |  | Relleno sin compactar | 13d | 2024-05-13 | 2024-05-28 | A5090 FF+3d, A5080, A2790 | 86d | 0d | grupo 1 |
| A5020 |  | Relleno afirmado | 5d | 2024-05-14 | 2024-05-19 | A5090, A2800 | 113.5d | 6d | grupo 1 |
|  | 3 | **Geotextil** |  | 2024-03-21 | 2024-05-04 |  |  |  |  |
| A5060 |  | Instalación de Geotextil 400 gr/m2 | 35d | 2024-03-21 | 2024-05-04 | A5070 SS, A2840 | 0d |  | grupo 1 |
| A5070 |  | Zanja de anclaje | 35d | 2024-03-21 | 2024-05-04 | A5006 SS+6d, A2850 | 0d |  | grupo 1 |
|  | 4 | **Colocación de Roca** |  | 2024-03-25 | 2024-05-14 |  |  |  |  |
| A5080 |  | Colocación de roca en uña | 39d | 2024-03-25 | 2024-05-12 | A5060 SS+3d, A2860 | 0d |  | grupo 1 |
| A5090 |  | Colocación de roca en talud | 37d | 2024-03-30 | 2024-05-14 | A5080 SS+3d, A2870 | 4d | 0d | grupo 1 |
|  | 6 | **Accesos** |  | 2024-05-14 | 2024-05-29 |  |  |  |  |
| A5580 |  | Encofrado y desencofrado pavimento rígido e=0.15m | 8d | 2024-05-14 | 2024-05-23 | A5090, A1880 | 111d | 0d | grupo 1 |
| A5570 |  | Concreto clase C (f'c=280 kg/cm2) en losa | 2.5d | 2024-05-23 | 2024-05-25 | A5580, A1900 | 117.5d | 0d | grupo 1 |
| A5590 |  | Junta en Pavimentos con Pasadores | 2.5d | 2024-05-23 | 2024-05-25 | A5570 SS, A1890 | 117.5d | 0d | grupo 1 |
| A5600 |  | Concreto Ciclopeo f'c=210 kg/cm2 + 30% PM | 2.5d | 2024-05-25 | 2024-05-29 | A5570, A5590 | 117.5d | 114.5d | grupo 1 |
|  | 8 | **DI-PR-24A-I** |  | 2024-02-26 | 2024-07-10 |  |  |  |  |
|  | 1 | **Excavaciones** |  | 2024-02-26 | 2024-03-28 |  |  |  |  |
| A6360 |  | Desbroce | 26d | 2024-02-26 | 2024-03-27 | A4880 | 22d | 0d | grupo 1 |
| A6370 |  | Remoción de dique existente | 26d | 2024-02-26 | 2024-03-27 | A6360 SS, A4890 | 22d | 0d | grupo 1 |
| A6380 |  | Excavación de cimentación | 26d | 2024-02-26 | 2024-03-27 | A6370 SS, A4900 | 22d | 0d | grupo 1 |
| A6385 |  | Excavación localizada - Sobreexcavación | 26d | 2024-02-26 | 2024-03-27 | A6380 SS, A4905 | 23d | 0d | grupo 1 |
| A6400 |  | Excavación de uña | 21d | 2024-02-29 | 2024-03-24 | A6370 SS+3d, A4920 | 89d | 5d | grupo 1 |
| A6390 |  | Perfilado y conformación de plataforma de fundación | 21d | 2024-03-04 | 2024-03-28 | A6385 SS+6d, A4910 | 23d | 1d | grupo 1 |

| ID | WBS | Activity | Duration | Start | Finish | Predecessors | Total float | Free float | Filtro |
| --- | --- | --- | --- | --- | --- | --- | --- | --- | --- |
|  | 2 | **Rellenos** |  | 2024-04-17 | 2024-07-10 |  |  |  |  |
| A6480 |  | Relleno con material granular | 34d | 2024-04-17 | 2024-05-28 | A6390 SS+6d, A4260 | 12d | 0d | grupo 1 |
| A6485 |  | Relleno con material seleccionado | 34d | 2024-04-17 | 2024-05-28 | A6480 SS | 12d | 0d | grupo 1 |
| A6486 |  | Perfilado de talud del dique | 27d | 2024-04-24 | 2024-05-26 | A6485 SS+6d, A4265 | 12d | 2d | grupo 1 |
| A6495 |  | Grava para drenaje | 27d | 2024-05-16 | 2024-06-18 | A6485 SS+12d, A4310 | 75d | 1d | grupo 1 |
| A6490 |  | Relleno sin compactar | 15d | 2024-06-21 | 2024-07-10 | A6570 FF+3d, A6560, A4270 | 68d | 24d | grupo 1 |
| A6500 |  | Relleno afirmado | 5d | 2024-07-04 | 2024-07-10 | A6570, A4280 | 78.5d | 27d | grupo 1 |
|  | 3 | **Geotextil** |  | 2024-05-09 | 2024-06-12 |  |  |  |  |
| A6540 |  | Instalación de Geotextil 400 gr/m2 | 28d | 2024-05-09 | 2024-06-12 | A6550 SS, A4320 | 6d | 0d | grupo 1 |
| A6550 |  | Zanja de anclaje | 28d | 2024-05-09 | 2024-06-12 | A6486 SS+6d, A4330 | 6d | 0d | grupo 1 |
|  | 4 | **Colocación de Roca** |  | 2024-05-18 | 2024-07-04 |  |  |  |  |
| A6560 |  | Colocación de roca en uña | 28d | 2024-05-18 | 2024-06-21 | A6540 SS+3d, A4340 | 1d | 0d | grupo 1 |
| A6570 |  | Colocación de roca en talud | 31d | 2024-05-27 | 2024-07-04 | A6560 SS+6d, A4350 | 0d |  | grupo 1 |
|  | 5 | **DE-PR-17bis-D** |  | 2024-03-27 | 2024-05-30 |  |  |  |  |
|  | 1 | **Excavaciones** |  | 2024-03-27 | 2024-04-04 |  |  |  |  |
| A4140 |  | Desbroce | 2d | 2024-03-27 | 2024-03-31 | A6360 | 22d | 0d | grupo 1 |
| A4160 |  | Excavación de cimentación | 2d | 2024-03-27 | 2024-03-31 | A4140 SS, A6380 | 22d | 0d | grupo 1 |
| A4165 |  | Excavación localizada - Sobreexcavación | 2d | 2024-03-27 | 2024-03-31 | A4160 SS, A6385 | 74d | 13d | grupo 1 |
| A4170 |  | Perfilado y conformación de plataforma de fundación | 2d | 2024-04-01 | 2024-04-03 | A4160, A6390 | 22d | 10d | grupo 1 |
| A4180 |  | Excavación de uña | 2d | 2024-04-02 | 2024-04-04 | A4160 SS+3d, A6400 | 84d | 13d | grupo 1 |
|  | 2 | **Rellenos** |  | 2024-04-15 | 2024-05-30 |  |  |  |  |
| A4260 |  | Relleno con material granular | 2d | 2024-04-15 | 2024-04-17 | A4170, A5000 | 12d | 0d | grupo 1 |
| A4265 |  | Perfilado de talud del dique | 2d | 2024-04-18 | 2024-04-20 | A4260, A5006 | 15d | 3d | grupo 1 |
| A4310 |  | Grava para drenaje | 2d | 2024-05-14 | 2024-05-16 | A4265, A5050 | 75d | 0d | grupo 1 |
| A4280 |  | Relleno afirmado | 2d | 2024-05-27 | 2024-05-29 | A4350, A5020 | 107.5d | 29d | grupo 1 |
| A4270 |  | Relleno sin compactar | 2d | 2024-05-28 | 2024-05-30 | A4340, A5010 | 86d | 18d | grupo 1 |

| ID | WBS | Activity | Duration | Start | Finish | Predecessors | Total float | Free float | Calendar | Filtro |
| --- | --- | --- | --- | --- | --- | --- | --- | --- | --- | --- |
|  | 3 | **Geotextil** |  | 2024-05-04 | 2024-05-09 |  |  |  |  |  |
| A4320 |  | Instalación de Geotextil 400 gr/m2 | 4d | 2024-05-04 | 2024-05-09 | A4330 SS, A5060 | 4d | 0d |  | grupo 1 |
| A4330 |  | Zanja de anclaje | 4d | 2024-05-04 | 2024-05-09 | A4265, A5070 | 4d | 0d |  | grupo 1 |
|  | 4 | **Colocación de Roca** |  | 2024-05-13 | 2024-05-26 |  |  |  |  |  |
| A4340 |  | Colocación de roca en uña | 5d | 2024-05-13 | 2024-05-18 | A4320 SS+3d, A5080 | 0d |  |  | grupo 1 |
| A4350 |  | Colocación de roca en talud | 7d | 2024-05-18 | 2024-05-26 | A4340, A5090 | 0d |  |  | grupo 1 |
|  | 4 | **DI-PR-11-D** |  | 2024-04-16 | 2024-10-19 |  |  |  |  |  |
|  | 1 | **Excavaciones** |  | 2024-04-16 | 2024-05-24 |  |  |  |  |  |
| A3400 |  | Desbroce | 26d | 2024-04-16 | 2024-05-17 | A4140 | 61d | 0d | 2T - 6x1 - 8 hr - Cañete - paro en avenidas | grupo 1 |
| A3410 |  | Remoción de dique existente | 26d | 2024-04-16 | 2024-05-17 | A3400 SS | 61d | 0d | 2T - 6x1 - 8 hr - Cañete - paro en avenidas | grupo 1 |
| A3420 |  | Excavación de cimentación | 26d | 2024-04-16 | 2024-05-17 | A3410 SS, A4160 | 61d | 0d | 2T - 6x1 - 8 hr - Cañete - paro en avenidas | grupo 1 |
| A3425 |  | Excavación localizada - Sobreexcavación | 26d | 2024-04-16 | 2024-05-17 | A3420 SS, A4165 | 61d | 0d | 2T - 6x1 - 8 hr - Cañete - paro en avenidas | grupo 1 |
| A3440 |  | Excavación de uña | 17d | 2024-04-19 | 2024-05-10 | A3410 SS+3d, A4180 | 71d | 57d | 2T - 6x1 - 8 hr - Cañete - paro en avenidas | grupo 1 |
| A3430 |  | Perfilado y conformación de plataforma de fundación | 26d | 2024-04-23 | 2024-05-24 | A3425 SS+6d, A4170 | 61d | 41d | 2T - 6x1 - 8 hr - Cañete - paro en avenidas | grupo 1 |
|  | 2 | **Rellenos** |  | 2024-06-19 | 2024-10-08 |  |  |  |  |  |
| A3520 |  | Relleno con material granular | 46d | 2024-06-19 | 2024-08-15 | A3430 SS+6d, A19760 | 20d | 0d | 2T - 6x1 - 8 hr - Cañete - paro en avenidas | grupo 1 |
| A3525 |  | Relleno con material seleccionado | 46d | 2024-06-19 | 2024-08-15 | A3520 SS, A19765 | 20d | 0d | 2T - 6x1 - 8 hr - Cañete - paro en avenidas | grupo 1 |
| A3526 |  | Perfilado de talud del dique | 35d | 2024-07-04 | 2024-08-16 | A3525 SS+12d, A19766 | 20d | 0d | 2T - 6x1 - 8 hr - Cañete - paro en avenidas | grupo 1 |
| A3570 |  | Grava para drenaje | 18d | 2024-08-15 | 2024-09-06 | A3525, A19810 | 39d |  | 2T - 6x1 - 8 hr - Cañete - paro en avenidas | grupo 1 |
| A3530 |  | Relleno sin compactar | 12d | 2024-09-21 | 2024-10-05 | A3610 FF+3d, A3600, A19770 | 14d |  | 2T - 6x1 - 8 hr - Cañete - paro en avenidas | grupo 1 |
| A3540 |  | Relleno afirmado | 5d | 2024-10-02 | 2024-10-08 | A3610, A19780 | 12d |  | 2T - 6x1 - 8 hr - Cañete - paro en avenidas | grupo 1 |
|  | 3 | **Geotextil** |  | 2024-07-08 | 2024-08-17 |  |  |  |  |  |
| A3580 |  | Instalación de Geotextil 400 gr/m2 | 33d | 2024-07-08 | 2024-08-17 | A3590 SS, A19820 | 20d | 6d | 2T - 6x1 - 8 hr - Cañete - paro en avenidas | grupo 1 |
| A3590 |  | Zanja de anclaje | 33d | 2024-07-08 | 2024-08-17 | A3526 SS+3d, A19830 | 20d | 0d | 2T - 6x1 - 8 hr - Cañete - paro en avenidas | grupo 1 |

| ID | WBS | Activity | Duration | Start | Finish | Predecessors | Total float | Free float | Calendar | Filtro |
| --- | --- | --- | --- | --- | --- | --- | --- | --- | --- | --- |
|  | 4 | **Colocación de Roca** |  | 2024-07-18 | 2024-10-02 |  |  |  |  |  |
| A3600 |  | Colocación de roca en uña | 40d | 2024-07-18 | 2024-09-06 | A3580 SS+3d, A19840, A3440 | 14d | 13d | 2T - 6x1 - 8 hr - Cañete - paro en avenidas | grupo 1 |
| A3610 |  | Colocación de roca en talud | 42d | 2024-08-13 | 2024-10-02 | A3600 SS+6d, A19850 | 0d |  | 2T - 6x1 - 8 hr - Cañete - paro en avenidas | grupo 1 |
|  | 6 | **Accesos** |  | 2024-10-02 | 2024-10-19 |  |  |  |  |  |
| A4100 |  | Encofrado y desencofrado pavimento rígido e=0.15m | 9d | 2024-10-02 | 2024-10-13 | A3610, A5580 | 3d | 0d | 2T - 6x1 - 8 hr - Cañete - paro en avenidas | grupo 1 |
| A4090 |  | Concreto clase C (f'c=280 kg/cm2) en losa | 2.5d | 2024-10-14 | 2024-10-16 | A4100, A5570 | 3d | 0d | 2T - 6x1 - 8 hr - Cañete - paro en avenidas | grupo 1 |
| A4110 |  | Junta en Pavimentos con Pasadores | 2.5d | 2024-10-14 | 2024-10-16 | A4090 SS, A5590 | 3d | 0d | 2T - 6x1 - 8 hr - Cañete - paro en avenidas | grupo 1 |
| A4120 |  | Concreto Ciclopeo f'c=210 kg/cm2 + 30% PM | 2.5d | 2024-10-16 | 2024-10-19 | A4090, A5600, A4110 | 3d |  | 2T - 6x1 - 8 hr - Cañete - paro en avenidas | grupo 1 |
|  | 24 | **DI-PR-55-D** |  | 2023-11-02 | 2024-07-02 |  |  |  |  |  |
|  | 1 | **Época Estiaje 2023** |  | 2023-11-02 | 2023-12-16 |  |  |  |  |  |
|  | 1 | **Excavaciones** |  | 2023-11-02 | 2023-11-25 |  |  |  |  |  |
| A18200 |  | Desbroce | 15d | 2023-11-02 | 2023-11-19 | A1020 | 0d |  | 2T - 6x1 - 8 hr - Cañete - paro en avenidas | grupo 2 |
| A18210 |  | Remoción de dique existente | 15d | 2023-11-02 | 2023-11-19 | A18200 SS | 0d |  | 2T - 6x1 - 8 hr - Cañete - paro en avenidas | grupo 2 |
| A18220 |  | Excavación de cimentación | 15d | 2023-11-02 | 2023-11-19 | A18210 SS | 0d |  | 2T - 6x1 - 8 hr - Cañete - paro en avenidas | grupo 2 |
| A18225 |  | Excavación localizada - Sobreexcavación | 15d | 2023-11-02 | 2023-11-19 | A18220 SS | 0d |  | 2T - 6x1 - 8 hr - Cañete - paro en avenidas | grupo 2 |
| A18240 |  | Excavación de uña | 17d | 2023-11-06 | 2023-11-25 | A18220 SS+3d | 121d | 1d | 2T - 6x1 - 8 hr - Cañete - paro en avenidas | grupo 2 |
| A18230 |  | Perfilado y conformación de plataforma de fundación | 10d | 2023-11-09 | 2023-11-21 | A18225 SS+6d | 5d | 0d | 2T - 6x1 - 8 hr - Cañete - paro en avenidas | grupo 2 |
|  | 2 | **Rellenos** |  | 2023-11-16 | 2023-12-12 |  |  |  |  |  |
| A18320 |  | Relleno con material granular | 15d | 2023-11-16 | 2023-12-03 | A18230 SS+6d | 99d | 0d | 2T - 6x1 - 8 hr - Cañete - paro en avenidas | grupo 2 |
| A18325 |  | Perfilado de talud del dique | 15d | 2023-11-23 | 2023-12-12 | A18320 SS+6d | 99d | 0d | 2T - 6x1 - 8 hr - Cañete - paro en avenidas | grupo 2 |
| A18370 |  | Grava para drenaje | 3d | 2023-12-04 | 2023-12-07 | A18320 | 163d | 7d | 2T - 6x1 - 8 hr - Cañete - paro en avenidas | grupo 2 |
|  | 3 | **Geotextil** |  | 2023-11-30 | 2023-12-15 |  |  |  |  |  |
| A18380 |  | Instalación de Geotextil 400 gr/m2 | 12d | 2023-11-30 | 2023-12-15 | A18390 SS | 99d | 0d | 2T - 6x1 - 8 hr - Cañete - paro en avenidas | grupo 2 |
| A18390 |  | Zanja de anclaje | 12d | 2023-11-30 | 2023-12-15 | A18325 SS+6d | 99d | 0d | 2T - 6x1 - 8 hr - Cañete - paro en avenidas | grupo 2 |

| ID | WBS | Activity | Duration | Start | Finish | Predecessors | Total float | Free float | Calendar | Filtro |
| --- | --- | --- | --- | --- | --- | --- | --- | --- | --- | --- |
|  | 4 | **Colocación de Roca** |  | 2023-12-07 | 2023-12-16 |  |  |  |  |  |
| A18400 |  | Colocación de roca en uña | 7d | 2023-12-07 | 2023-12-16 | A18380 SS+6d | 99d | 0d | 2T - 6x1 - 8 hr - Cañete - paro en avenidas | grupo 2 |
| A18410 |  | Colocación de roca en talud | 1d | 2023-12-15 | 2023-12-16 | A18400 SS+6d | 105d | 6d | 2T - 6x1 - 8 hr - Cañete - paro en avenidas | grupo 2 |
|  | 2 | **Época Estiaje 2024** |  | 2024-04-16 | 2024-05-15 |  |  |  |  |  |
|  | 1 | **Rellenos** |  | 2024-05-13 | 2024-05-15 |  |  |  |  |  |
| A18340 |  | Relleno afirmado | 2d | 2024-05-13 | 2024-05-15 | A19570 | 138d |  | 2T - 6x1 - 8 hr - Cañete - paro en avenidas | grupo 2 |
|  | 2 | **Colocación de Roca** |  | 2024-04-16 | 2024-05-12 |  |  |  |  |  |
| A19560 |  | Colocación de roca en uña | 15d | 2024-04-16 | 2024-05-04 | A18400, A7300 | 99d | 0d | 2T - 6x1 - 8 hr - Cañete - paro en avenidas | grupo 2 |
| A19570 |  | Colocación de roca en talud | 16d | 2024-04-23 | 2024-05-12 | A19560 SS+6d, A18410, A7310 | 99d | 0d | 2T - 6x1 - 8 hr - Cañete - paro en avenidas | grupo 2 |
|  | 3 | **Muros** |  | 2024-05-13 | 2024-07-02 |  |  |  |  |  |
|  | 1 | **Cimiento** |  | 2024-05-13 | 2024-05-25 |  |  |  |  |  |
| A20570 |  | Concreto de Nivelacion (f'c=100 kg/cm2) | 2d | 2024-05-13 | 2024-05-15 | A19570 | 99d | 0d | 2T - 6x1 - 8 hr - Cañete - paro en avenidas | muros |
| A20571 |  | Acero de refuerzo f'y=4200kg/cm2 - cimiento | 2d | 2024-05-16 | 2024-05-18 | A20570 SS+3d | 99d | 0d | 2T - 6x1 - 8 hr - Cañete - paro en avenidas | muros |
| A20572 |  | Encofrado y Desencofrado Cara Oculta | 3d | 2024-05-20 | 2024-05-23 | A20571 SS+3d | 99d | 0d | 2T - 6x1 - 8 hr - Cañete - paro en avenidas | muros |
| A20573 |  | Juntas de dilatación | 3d | 2024-05-20 | 2024-05-23 | A20572 SS | 129d | 15d | 2T - 6x1 - 8 hr - Cañete - paro en avenidas | muros |
| A20574 |  | Concreto Clase C (f'c=280 kg/cm2) Premezclado - Cimientos reforzados | 2d | 2024-05-23 | 2024-05-25 | A20572 SS+3d, A20570 | 99d | 0d | 2T - 6x1 - 8 hr - Cañete - paro en avenidas | muros |
|  | 2 | **Muro** |  | 2024-06-06 | 2024-07-02 |  |  |  |  |  |
| A20575 |  | Acero de refuerzo f'y=4200kg/cm2 - muro | 2d | 2024-06-06 | 2024-06-09 | A20574 SS+12d, A20571 | 99d | 0d | 2T - 6x1 - 8 hr - Cañete - paro en avenidas | muros |
| A20576 |  | Encofrado y Desencofrado Caravista | 2d | 2024-06-11 | 2024-06-13 | A20575 SS+3d, A20572 | 99d | 0d | 2T - 6x1 - 8 hr - Cañete - paro en avenidas | muros |
| A20577 |  | Juntas de dilatación | 2d | 2024-06-11 | 2024-06-13 | A20576 SS, A20573 | 114d |  | 2T - 6x1 - 8 hr - Cañete - paro en avenidas | muros |
| A20590 |  | Concreto Clase C (f'c=280 kg/cm2) Premezclado - Muros de contencion | 2d | 2024-06-14 | 2024-06-16 | A20576 SS+3d | 99d | 0d | 2T - 6x1 - 8 hr - Cañete - paro en avenidas | muros |
| A20650 |  | Pintura bituminosa | 2d | 2024-06-28 | 2024-07-02 | A20590 SS+12d | 99d |  | 2T - 6x1 - 8 hr - Cañete - paro en avenidas | muros |
|  | 21 | **DI-PR-47-D** |  | 2023-11-20 | 2024-08-13 |  |  |  |  |  |
|  | 6 | **Época Estiaje 2023** |  | 2023-11-20 | 2023-12-16 |  |  |  |  |  |
|  | 1 | **Excavaciones** |  | 2023-11-20 | 2023-12-16 |  |  |  |  |  |
| A15980 |  | Desbroce | 22d | 2023-11-20 | 2023-12-16 | A18200 | 0d |  | 2T - 6x1 - 8 hr - Cañete - paro en avenidas | grupo 2 |
| A15990 |  | Remoción de dique existente | 22d | 2023-11-20 | 2023-12-16 | A15980 SS, A18210 | 0d |  | 2T - 6x1 - 8 hr - Cañete - paro en avenidas | grupo 2 |
| A16000 |  | Excavación de cimentación | 22d | 2023-11-20 | 2023-12-16 | A15990 SS, A18220 | 0d |  | 2T - 6x1 - 8 hr - Cañete - paro en avenidas | grupo 2 |
| A16005 |  | Excavación localizada - Sobreexcavación | 22d | 2023-11-20 | 2023-12-16 | A16000 SS, A18225 | 0d |  | 2T - 6x1 - 8 hr - Cañete - paro en avenidas | grupo 2 |
| A16010 |  | Perfilado y conformación de plataforma de fundación | 16d | 2023-11-27 | 2023-12-16 | A16005 SS+6d, A18230 | 0d |  | 2T - 6x1 - 8 hr - Cañete - paro en avenidas | grupo 2 |
| A16020 |  | Excavación de uña | 16d | 2023-11-27 | 2023-12-16 | A16005 SS+6d, A18240 | 120d | 0d | 2T - 6x1 - 8 hr - Cañete - paro en avenidas | grupo 2 |

| ID | WBS | Activity | Duration | Start | Finish | Predecessors | Total float | Free float | Calendar | Filtro |
| --- | --- | --- | --- | --- | --- | --- | --- | --- | --- | --- |
|  | 2 | **Rellenos** |  | 2023-12-04 | 2023-12-16 |  |  |  |  |  |
| A16100 |  | Relleno con material granular | 10d | 2023-12-04 | 2023-12-16 | A16010 SS+6d, A18320 | 162d | 0d | 2T - 6x1 - 8 hr - Cañete - paro en avenidas | grupo 2 |
| A16105 |  | Relleno con material seleccionado | 10d | 2023-12-04 | 2023-12-16 | A16100 SS | 162d | 0d | 2T - 6x1 - 8 hr - Cañete - paro en avenidas | grupo 2 |
| A16115 |  | Perfilado de talud del dique | 4d | 2023-12-12 | 2023-12-16 | A16105 SS+6d | 162d |  | 2T - 6x1 - 8 hr - Cañete - paro en avenidas |  |
|  | 7 | **Época Estiaje 2024** |  | 2024-04-16 | 2024-08-13 |  |  |  |  |  |
|  | 1 | **Excavaciones** |  | 2024-04-16 | 2024-04-26 |  |  |  |  |  |
| A19580 |  | Desbroce | 7d | 2024-04-16 | 2024-04-24 | A7100 | 0d |  | 2T - 6x1 - 8 hr - Cañete - paro en avenidas | grupo 2 |
| A19590 |  | Remoción de dique existente | 7d | 2024-04-16 | 2024-04-24 | A19580 SS, A7110 | 155d |  | 2T - 6x1 - 8 hr - Cañete - paro en avenidas | grupo 2 |
| A19600 |  | Excavación de cimentación | 7d | 2024-04-16 | 2024-04-24 | A19580 SS, A7120 | 9d | 0d | 2T - 6x1 - 8 hr - Cañete - paro en avenidas | grupo 2 |
| A19605 |  | Excavación localizada - Sobreexcavación | 7d | 2024-04-16 | 2024-04-24 | A19600 SS, A7125 | 9d | 0d | 2T - 6x1 - 8 hr - Cañete - paro en avenidas | grupo 2 |
| A19610 |  | Perfilado y conformación de plataforma de fundación | 5d | 2024-04-19 | 2024-04-25 | A19605 SS+3d, A7130 | 9d | 0d | 2T - 6x1 - 8 hr - Cañete - paro en avenidas | grupo 2 |
| A19620 |  | Excavación de uña | 3d | 2024-04-23 | 2024-04-26 | A19610 SS+3d, A7140 | 153d |  | 2T - 6x1 - 8 hr - Cañete - paro en avenidas | grupo 2 |
|  | 2 | **Rellenos** |  | 2024-04-26 | 2024-08-13 |  |  |  |  |  |
| A19640 |  | Relleno con material granular | 67d | 2024-04-26 | 2024-07-17 | A19610 SS+6d | 9d | 0d | 2T - 6x1 - 8 hr - Cañete - paro en avenidas | grupo 2 |
| A19645 |  | Relleno con material seleccionado | 67d | 2024-04-26 | 2024-07-17 | A19640 SS | 16d | 0d | 2T - 6x1 - 8 hr - Cañete - paro en avenidas | grupo 2 |
| A19646 |  | Perfilado de talud del dique | 67d | 2024-04-30 | 2024-07-20 | A19645 SS+3d | 16d | 0d | 2T - 6x1 - 8 hr - Cañete - paro en avenidas | grupo 2 |
| A19690 |  | Grava para drenaje | 15d | 2024-07-17 | 2024-08-04 | A19645 | 71d |  | 2T - 6x1 - 8 hr - Cañete - paro en avenidas | grupo 2 |
| A19650 |  | Relleno sin compactar | 8d | 2024-07-31 | 2024-08-10 | A16180 | 67d |  | 2T - 6x1 - 8 hr - Cañete - paro en avenidas | grupo 2 |
| A19660 |  | Relleno afirmado | 4d | 2024-08-08 | 2024-08-13 | A16190 | 65d |  | 2T - 6x1 - 8 hr - Cañete - paro en avenidas | grupo 2 |
|  | 3 | **Geotextil** |  | 2024-05-08 | 2024-07-19 |  |  |  |  |  |
| A16160 |  | Instalación de Geotextil 400 gr/m2 | 60d | 2024-05-08 | 2024-07-19 | A16170 SS | 16d | 0d | 2T - 6x1 - 8 hr - Cañete - paro en avenidas | grupo 2 |
| A16170 |  | Zanja de anclaje | 60d | 2024-05-08 | 2024-07-19 | A19646 SS+6d | 16d | 0d | 2T - 6x1 - 8 hr - Cañete - paro en avenidas | grupo 2 |
|  | 4 | **Colocación de Roca** |  | 2024-05-15 | 2024-08-08 |  |  |  |  |  |
| A16180 |  | Colocación de roca en uña | 63d | 2024-05-15 | 2024-07-31 | A16160 SS+6d | 16d | 0d | 2T - 6x1 - 8 hr - Cañete - paro en avenidas | grupo 2 |
| A16190 |  | Colocación de roca en talud | 63d | 2024-05-22 | 2024-08-08 | A16180 SS+6d | 65d | 0d | 2T - 6x1 - 8 hr - Cañete - paro en avenidas | grupo 2 |

| ID | WBS | Activity | Duration | Start | Finish | Predecessors | Total float | Free float | Filtro |
| --- | --- | --- | --- | --- | --- | --- | --- | --- | --- |
|  | 22 | **DI-PR-51-I** |  | 2023-12-16 | 2024-09-24 |  |  |  |  |
|  | 1 | **Excavaciones** |  | 2023-12-16 | 2024-01-10 |  |  |  |  |
| A16720 |  | Desbroce | 12d | 2023-12-16 | 2023-12-31 | A15980 | 27d | 0d | grupo 2 |
| A16730 |  | Remoción de dique existente | 12d | 2023-12-16 | 2023-12-31 | A16720 SS, A15990 | 27d | 0d | grupo 2 |
| A16740 |  | Excavación de cimentación | 12d | 2023-12-16 | 2023-12-31 | A16730 SS, A16000 | 27d | 0d | grupo 2 |
| A16745 |  | Excavación localizada - Sobreexcavación | 12d | 2023-12-16 | 2023-12-31 | A16740 SS, A16005 | 72d | 0d | grupo 2 |
| A16760 |  | Excavación de uña | 16d | 2023-12-20 | 2024-01-10 | A16730 SS+3d, A16020 | 217d | 0d | grupo 2 |
| A16750 |  | Perfilado y conformación de plataforma de fundación | 7d | 2023-12-23 | 2024-01-03 | A16740 SS+6d, A16010 | 27d | 0d | grupo 2 |
|  | 2 | **Rellenos** |  | 2024-07-17 | 2024-09-24 |  |  |  |  |
| A16840 |  | Relleno con material granular | 19d | 2024-07-17 | 2024-08-10 | A19535, A19640 | 9d | 0d | grupo 2 |
| A16845 |  | Relleno con material seleccionado | 19d | 2024-07-17 | 2024-08-10 | A16840 SS | 9d | 0d | grupo 2 |
| A16846 |  | Perfilado de talud del dique | 14d | 2024-07-24 | 2024-08-11 | A16845 SS+6d | 9d | 0d | grupo 2 |
| A16860 |  | Relleno afirmado | 2.5d | 2024-09-21 | 2024-09-24 | A16930 | 29.5d |  | grupo 2 |
|  | 3 | **Geotextil** |  | 2024-08-01 | 2024-08-23 |  |  |  |  |
| A16900 |  | Instalación de Geotextil 400 gr/m2 | 18d | 2024-08-01 | 2024-08-23 | A16910 SS | 9d | 0d | grupo 2 |
| A16910 |  | Zanja de anclaje | 18d | 2024-08-01 | 2024-08-23 | A16846 SS+6d | 9d | 0d | grupo 2 |
|  | 4 | **Colocación de Roca** |  | 2024-08-09 | 2024-09-21 |  |  |  |  |
| A16920 |  | Colocación de roca en uña | 35d | 2024-08-09 | 2024-09-20 | A16900 SS+6d, A16180 | 9d | 0d | grupo 2 |
| A16930 |  | Colocación de roca en talud | 30d | 2024-08-16 | 2024-09-21 | A16920 SS+6d | 29.5d | 0d | grupo 2 |
|  | 6 | **Muros** |  | 2024-01-03 | 2024-06-25 |  |  |  |  |
|  | 1 | **Cimiento** |  | 2024-01-03 | 2024-04-04 |  |  |  |  |
| A19440 |  | Concreto de Nivelacion (f'c=100 kg/cm2) | 20d | 2024-01-03 | 2024-01-26 | A16750 | 27d | 0d | muros |
| A19441 |  | Acero de refuerzo f'y=4200kg/cm2 - cimiento | 48d | 2024-01-06 | 2024-03-02 | A19440 SS+3d | 38d | 0d | muros |
| A19442 |  | Encofrado y Desencofrado Cara Oculta | 57d | 2024-01-10 | 2024-03-16 | A19441 SS+3d | 38d | 0d | muros |
| A19510 |  | Juntas de dilatación | 57d | 2024-01-10 | 2024-03-16 | A19442 SS | 123d | 0d | muros |
| A19450 |  | Concreto Clase C (f'c=280 kg/cm2) Premezclado - Cimientos reforzados | 57d | 2024-01-26 | 2024-04-04 | A19442 SS+3d, A19440 | 27d | 0d | muros |

| ID | WBS | Activity | Duration | Start | Finish | Predecessors | Total float | Free float | Filtro |
| --- | --- | --- | --- | --- | --- | --- | --- | --- | --- |
|  | 2 | **Muro** |  | 2024-03-02 | 2024-06-25 |  |  |  |  |
| A19500 |  | Acero de refuerzo f'y=4200kg/cm2 - muro | 61d | 2024-03-02 | 2024-05-16 | A19450 SS+18d, A19441 | 47d | 9d | muros |
| A19501 |  | Encofrado y Desencofrado Caravista | 58d | 2024-03-16 | 2024-05-26 | A19500 SS+3d, A19442 | 38d | 0d | muros |
| A19530 |  | Juntas de dilatación | 58d | 2024-03-16 | 2024-05-26 | A19501 SS, A19510 | 123d | 15d | muros |
| A19502 |  | Concreto Clase C (f'c=280 kg/cm2) Premezclado - Muros de contencion | 53d | 2024-04-04 | 2024-06-06 | A19501 SS+3d, A19450 | 27d | 0d | muros |
| A19535 |  | Pintura bituminosa | 56d | 2024-04-18 | 2024-06-25 | A19502 SS+12d | 27d | 18d | muros |
|  | 12 | **DI-PR-42-1-I** |  | 2024-01-02 | 2024-10-19 |  |  |  |  |
|  | 1 | **Excavaciones** |  | 2024-01-02 | 2024-01-20 |  |  |  |  |
| A9320 |  | Desbroce | 10d | 2024-01-02 | 2024-01-13 | A16720 | 63d | 0d | grupo 2 |
| A9340 |  | Excavación de cimentación | 10d | 2024-01-02 | 2024-01-13 | A9320 SS, A16740 | 68d | 0d | grupo 2 |
| A9345 |  | Excavación localizada - Sobreexcavación | 10d | 2024-01-02 | 2024-01-13 | A9340 SS, A16745 | 72d | 0d | grupo 2 |
| A9350 |  | Perfilado y conformación de plataforma de fundación | 8d | 2024-01-09 | 2024-01-18 | A9340 SS+6d, A16750 | 80d | 2d | grupo 2 |
| A9360 |  | Excavación de uña | 9d | 2024-01-10 | 2024-01-20 | A9340 SS+6d, A16760 | 217d | 0d | grupo 2 |
|  | 2 | **Rellenos** |  | 2024-08-10 | 2024-10-19 |  |  |  |  |
| A9440 |  | Relleno con material granular | 15d | 2024-08-10 | 2024-08-28 | A20500, A16840 | 28d | 0d | grupo 2 |
| A9445 |  | Relleno con material seleccionado | 15d | 2024-08-10 | 2024-08-28 | A9440 SS | 28d | 0d | grupo 2 |
| A9446 |  | Perfilado de talud del dique | 24d | 2024-08-17 | 2024-09-15 | A9445 SS+6d | 28d | 0d | grupo 2 |
| A9460 |  | Relleno afirmado | 2d | 2024-10-16 | 2024-10-18 | A9530 | 10d |  | grupo 2 |
| A9450 |  | Relleno sin compactar | 2d | 2024-10-17 | 2024-10-19 | A9530 FF+3d, A9520 | 9d |  | grupo 2 |
|  | 3 | **Geotextil** |  | 2024-08-21 | 2024-09-12 |  |  |  |  |
| A9500 |  | Instalación de Geotextil 400 gr/m2 | 18d | 2024-08-21 | 2024-09-12 | A9510 SS | 28d | 19d | grupo 2 |
| A9510 |  | Zanja de anclaje | 18d | 2024-08-21 | 2024-09-12 | A9446 SS+3d | 28d | 0d | grupo 2 |
|  | 4 | **Colocación de Roca** |  | 2024-09-20 | 2024-10-16 |  |  |  |  |
| A9520 |  | Colocación de roca en uña | 20d | 2024-09-20 | 2024-10-15 | A9500 SS+6d, A16920 | 9d | 0d | grupo 2 |
| A9530 |  | Colocación de roca en talud | 15d | 2024-09-27 | 2024-10-16 | A9520 SS+6d | 9d | 0d | grupo 2 |

| ID | WBS | Activity | Duration | Start | Finish | Predecessors | Total float | Free float | Filtro |
| --- | --- | --- | --- | --- | --- | --- | --- | --- | --- |
|  | 5 | **Muros** |  | 2024-01-13 | 2024-06-09 |  |  |  |  |
|  | 1 | **Cimiento** |  | 2024-01-13 | 2024-03-23 |  |  |  |  |
| A20420 |  | Concreto de Nivelacion (f'c=100 kg/cm2) | 14d | 2024-01-13 | 2024-01-30 | A9340 | 68d | 0d | muros |
| A20421 |  | Acero de refuerzo f'y=4200kg/cm2 - cimiento | 40d | 2024-01-17 | 2024-03-03 | A20420 SS+3d | 73d | 0d | muros |
| A20422 |  | Encofrado y Desencofrado Cara Oculta | 41d | 2024-01-20 | 2024-03-08 | A20421 SS+3d | 73d | 0d | muros |
| A20490 |  | Juntas de dilatación | 41d | 2024-01-20 | 2024-03-08 | A20422 SS | 125d | 0d | muros |
| A20430 |  | Concreto Clase C (f'c=280 kg/cm2) Premezclado - Cimientos reforzados | 46d | 2024-01-30 | 2024-03-23 | A20422 SS+3d, A20420 | 68d | 0d | muros |
|  | 2 | **Muro** |  | 2024-03-04 | 2024-06-09 |  |  |  |  |
| A20480 |  | Acero de refuerzo f'y=4200kg/cm2 - muro | 49d | 2024-03-04 | 2024-05-03 | A20430 SS+18d, A20421 | 79d | 1d | muros |
| A20481 |  | Encofrado y Desencofrado Caravista | 49d | 2024-03-08 | 2024-05-08 | A20480 SS+3d, A20422 | 78d | 0d | muros |
| A20483 |  | Juntas de dilatación | 49d | 2024-03-08 | 2024-05-08 | A20481 SS, A20490 | 125d | 24d | muros |
| A20482 |  | Concreto Clase C (f'c=280 kg/cm2) Premezclado - Muros de contencion | 54d | 2024-03-23 | 2024-05-29 | A20481 SS+3d, A20430 | 68d | 0d | muros |
| A20500 |  | Pintura bituminosa | 51d | 2024-04-09 | 2024-06-09 | A20482 SS+12d | 78d | 50d | muros |
|  | 16 | **DI-PR-42-2-I** |  | 2024-04-24 | 2024-04-28 |  |  |  |  |
|  | 1 | **Excavaciones** |  | 2024-04-24 | 2024-04-26 |  |  |  |  |
| A12280 |  | Desbroce | 2d | 2024-04-24 | 2024-04-26 | A19580 | 0d |  | grupo 2 |
| A12300 |  | Excavación de cimentación | 2d | 2024-04-24 | 2024-04-26 | A12280 SS | 88d | 0d | grupo 2 |
|  | 2 | **Rellenos** |  | 2024-04-26 | 2024-04-28 |  |  |  |  |
| A12400 |  | Relleno con material seleccionado | 2d | 2024-04-26 | 2024-04-28 | A12300 | 138d | 0d | grupo 2 |
|  | 14 | **DI-PR-42-3-I** |  | 2024-04-26 | 2024-05-15 |  |  |  |  |
|  | 1 | **Excavaciones** |  | 2024-04-26 | 2024-04-28 |  |  |  |  |
| A20030 |  | Desbroce | 2d | 2024-04-26 | 2024-04-28 | A12280 | 0d |  | grupo 2 |
| A20040 |  | Excavación de cimentación | 2d | 2024-04-26 | 2024-04-28 | A20030 SS, A12300 | 88d | 0d | grupo 2 |
|  | 2 | **Rellenos** |  | 2024-04-29 | 2024-05-03 |  |  |  |  |
| A20050 |  | Relleno con material granular | 3d | 2024-04-29 | 2024-05-03 | A20040, A12400 | 138d | 0d | grupo 2 |
| A20060 |  | Relleno con material seleccionado | 2.5d | 2024-04-29 | 2024-05-02 | A20050 SS | 138d | 0d |  |

| ID | WBS | Activity | Duration | Start | Finish | Predecessors | Total float | Free float | Filtro |
| --- | --- | --- | --- | --- | --- | --- | --- | --- | --- |
|  | 3 | **Geotextil** |  | 2024-05-02 | 2024-05-05 |  |  |  |  |
| A20520 |  | Instalación de Geotextil 400 gr/m2 | 2.5d | 2024-05-02 | 2024-05-05 | A20060 | 138d | 0d |  |
|  | 4 | **Colocación de Roca** |  | 2024-05-06 | 2024-05-15 |  |  |  |  |
| A20530 |  | Colocación de roca en talud | 2d | 2024-05-06 | 2024-05-08 | A20520 | 138d | 0d |  |
| A20540 |  | Protección de Talud con Colchón Reno 6m largo x e= 0.30cm | 6d | 2024-05-08 | 2024-05-15 | A20530 | 138d |  |  |
|  | 15 | **DI-PR-42-4-I** |  | 2024-04-29 | 2024-08-06 |  |  |  |  |
|  | 1 | **Excavaciones** |  | 2024-04-29 | 2024-05-01 |  |  |  |  |
| A20160 |  | Desbroce | 2d | 2024-04-29 | 2024-05-01 | A20030 | 0d |  | grupo 2 |
| A20170 |  | Excavación de cimentación | 2d | 2024-04-29 | 2024-05-01 | A20160 SS, A20040 | 88d | 0d | grupo 2 |
|  | 2 | **Rellenos** |  | 2024-08-03 | 2024-08-06 |  |  |  |  |
| A20180 |  | Relleno con material granular | 2d | 2024-08-03 | 2024-08-06 | A20270 | 70d | 0d | grupo 2 |
| A20550 |  | Relleno con material seleccionado | 2d | 2024-08-03 | 2024-08-06 | A20180 SS | 70d |  |  |
|  | 5 | **Muros** |  | 2024-06-06 | 2024-08-03 |  |  |  |  |
|  | 1 | **Cimiento** |  | 2024-06-06 | 2024-06-25 |  |  |  |  |
| A20190 |  | Concreto de Nivelacion (f'c=100 kg/cm2) | 2d | 2024-06-06 | 2024-06-09 | A20170, A19502 | 70d | 0d | muros |
| A20191 |  | Acero de refuerzo f'y=4200kg/cm2 - cimiento | 2d | 2024-06-11 | 2024-06-13 | A20190 SS+3d, A19500 | 70d | 0d | muros |
| A20192 |  | Encofrado y Desencofrado Cara Oculta | 8d | 2024-06-14 | 2024-06-23 | A20191 SS+3d, A19501 | 70d | 0d | muros |
| A20260 |  | Juntas de dilatación | 3d | 2024-06-14 | 2024-06-18 | A20192 SS, A19530 | 108d | 19d | muros |
| A20200 |  | Concreto Clase C (f'c=280 kg/cm2) Premezclado - Cimientos reforzados | 2d | 2024-06-22 | 2024-06-25 | A20192 SS+7d, A20190 | 70d | 0d | muros |
|  | 2 | **Muro** |  | 2024-07-08 | 2024-08-03 |  |  |  |  |
| A20250 |  | Acero de refuerzo f'y=4200kg/cm2 - muro | 2d | 2024-07-08 | 2024-07-10 | A20200 SS+12d, A20191 | 70d | 0d | muros |
| A20251 |  | Encofrado y Desencofrado Caravista | 2d | 2024-07-11 | 2024-07-13 | A20250 SS+3d, A20192 | 70d | 0d | muros |
| A20280 |  | Juntas de dilatación | 2d | 2024-07-11 | 2024-07-13 | A20251 SS, A20260 | 89d |  | muros |
| A20252 |  | Concreto Clase C (f'c=280 kg/cm2) Premezclado - Muros de contencion | 3d | 2024-07-15 | 2024-07-18 | A20251 SS+3d, A20200 | 70d | 0d | muros |
| A20270 |  | Pintura bituminosa | 4d | 2024-07-30 | 2024-08-03 | A20252 SS+12d | 70d | 0d | muros |

| ID | WBS | Activity | Duration | Start | Finish | Predecessors | Total float | Free float | Filtro |
| --- | --- | --- | --- | --- | --- | --- | --- | --- | --- |
|  | 25 | **DI-PR-42-5-I** |  | 2024-05-02 | 2024-08-09 |  |  |  |  |
|  | 1 | **Excavaciones** |  | 2024-05-02 | 2024-05-04 |  |  |  |  |
| A20290 |  | Desbroce | 2d | 2024-05-02 | 2024-05-04 | A20160 | 0d |  | grupo 2 |
| A20300 |  | Excavación de cimentación | 2d | 2024-05-02 | 2024-05-04 | A20290 SS, A20170 | 88d | 0d | grupo 2 |
|  | 2 | **Rellenos** |  | 2024-08-03 | 2024-08-06 |  |  |  |  |
| A20310 |  | Relleno con material seleccionado | 2d | 2024-08-03 | 2024-08-06 | A20400 | 68d | 0d | grupo 2 |
|  | 3 | **Colocación de Roca** |  | 2024-08-07 | 2024-08-09 |  |  |  |  |
| A20560 |  | Colocación de roca en talud | 2d | 2024-08-07 | 2024-08-09 | A20310 | 68d |  |  |
|  | 5 | **Muros** |  | 2024-05-29 | 2024-08-03 |  |  |  |  |
|  | 1 | **Cimiento** |  | 2024-05-29 | 2024-06-27 |  |  |  |  |
| A20320 |  | Concreto de Nivelacion (f'c=100 kg/cm2) | 2d | 2024-05-29 | 2024-05-31 | A20300, A20482 | 68d | 0d | muros |
| A20321 |  | Acero de refuerzo f'y=4200kg/cm2 - cimiento | 5d | 2024-06-01 | 2024-06-07 | A20320 SS+3d, A20480 | 68d | 0d | muros |
| A20322 |  | Encofrado y Desencofrado Cara Oculta | 15d | 2024-06-05 | 2024-06-23 | A20321 SS+3d, A20481 | 68d | 0d | muros |
| A20390 |  | Juntas de dilatación | 15d | 2024-06-05 | 2024-06-23 | A20322 SS, A20483 | 101d | 12d | muros |
| A20330 |  | Concreto Clase C (f'c=280 kg/cm2) Premezclado - Cimientos reforzados | 6d | 2024-06-20 | 2024-06-27 | A20322 SS+12d, A20320 | 68d | 0d | muros |
|  | 2 | **Muro** |  | 2024-07-05 | 2024-08-03 |  |  |  |  |
| A20380 |  | Acero de refuerzo f'y=4200kg/cm2 - muro | 6d | 2024-07-05 | 2024-07-12 | A20330 SS+12d, A20321 | 68d | 0d | muros |
| A20381 |  | Encofrado y Desencofrado Caravista | 4d | 2024-07-09 | 2024-07-13 | A20380 SS+3d, A20322 | 68d | 0d | muros |
| A20410 |  | Juntas de dilatación | 4d | 2024-07-09 | 2024-07-13 | A20381 SS, A20390 | 89d |  | muros |
| A20382 |  | Concreto Clase C (f'c=280 kg/cm2) Premezclado - Muros de contencion | 7d | 2024-07-12 | 2024-07-20 | A20381 SS+3d, A20330 | 68d | 0d | muros |
| A20400 |  | Pintura bituminosa | 6d | 2024-07-26 | 2024-08-03 | A20382 SS+12d | 68d | 0d | muros |
|  | 23 | **DI-PR-53-I** |  | 2024-01-13 | 2024-03-16 |  |  |  |  |
|  | 1 | **Excavaciones** |  | 2024-01-13 | 2024-02-02 |  |  |  |  |
| A17460 |  | Desbroce | 10d | 2024-01-13 | 2024-01-25 | A9320 | 63d | 0d | grupo 2 |
| A17470 |  | Remoción de dique existente | 10d | 2024-01-13 | 2024-01-25 | A17460 SS | 72d | 0d | grupo 2 |
| A17480 |  | Excavación de cimentación | 10d | 2024-01-13 | 2024-01-25 | A17470 SS, A9340 | 72d | 0d | grupo 2 |
| A17485 |  | Excavación localizada - Sobreexcavación | 10d | 2024-01-13 | 2024-01-25 | A17480 SS, A9345 | 72d | 0d | grupo 2 |
| A17490 |  | Perfilado y conformación de plataforma de fundación | 4d | 2024-01-20 | 2024-01-25 | A17480 SS+6d, A9350 | 78d | 0d | grupo 2 |
| A17500 |  | Excavación de uña | 11d | 2024-01-20 | 2024-02-02 | A17470 SS+3d, A9360 | 217d | 0d | grupo 2 |

| ID | WBS | Activity | Duration | Start | Finish | Predecessors | Total float | Free float | Filtro |
| --- | --- | --- | --- | --- | --- | --- | --- | --- | --- |
|  | 2 | **Rellenos** |  | 2024-01-25 | 2024-03-16 |  |  |  |  |
| A17580 |  | Relleno con material granular | 19d | 2024-01-25 | 2024-02-16 | A17490 | 118d | 0d | grupo 2 |
| A17585 |  | Relleno con material seleccionado | 19d | 2024-01-25 | 2024-02-16 | A17580 SS | 118d | 0d | grupo 2 |
| A17586 |  | Perfilado de talud del dique | 15d | 2024-02-01 | 2024-02-18 | A17585 SS+6d | 118d | 0d | grupo 2 |
| A17630 |  | Grava para drenaje | 3d | 2024-02-16 | 2024-02-20 | A17585, A18370 | 205d | 4d | grupo 2 |
| A17600 |  | Relleno afirmado | 2d | 2024-03-14 | 2024-03-16 | A17670 | 184d | 11d | grupo 2 |
|  | 3 | **Geotextil** |  | 2024-02-08 | 2024-02-21 |  |  |  |  |
| A17640 |  | Instalación de Geotextil 400 gr/m2 | 11d | 2024-02-08 | 2024-02-21 | A17650 SS | 118d | 0d | grupo 2 |
| A17650 |  | Zanja de anclaje | 11d | 2024-02-08 | 2024-02-21 | A17586 SS+6d | 118d | 0d | grupo 2 |
|  | 4 | **Colocación de Roca** |  | 2024-02-15 | 2024-03-14 |  |  |  |  |
| A17660 |  | Colocación de roca en uña | 23d | 2024-02-15 | 2024-03-13 | A17640 SS+6d | 118d | 0d | grupo 2 |
| A17670 |  | Colocación de roca en talud | 18d | 2024-02-22 | 2024-03-14 | A17660 SS+6d | 123d | 0d | grupo 2 |
|  | 9 | **DE-PR-39-I** |  | 2024-01-25 | 2024-04-03 |  |  |  |  |
|  | 1 | **Excavaciones** |  | 2024-01-25 | 2024-02-06 |  |  |  |  |
| A7100 |  | Desbroce | 5d | 2024-01-25 | 2024-01-31 | A17460 | 63d | 0d | grupo 2 |
| A7110 |  | Remoción de dique existente | 5d | 2024-01-25 | 2024-01-31 | A7100 SS, A17470 | 72d | 0d | grupo 2 |
| A7120 |  | Excavación de cimentación | 5d | 2024-01-25 | 2024-01-31 | A7110 SS, A17480 | 72d | 0d | grupo 2 |
| A7125 |  | Excavación localizada - Sobreexcavación | 5d | 2024-01-25 | 2024-01-31 | A7120 SS, A17485 | 72d | 63d | grupo 2 |
| A7130 |  | Perfilado y conformación de plataforma de fundación | 2d | 2024-02-01 | 2024-02-03 | A7120 SS+6d, A17490 | 72d | 11d | grupo 2 |
| A7140 |  | Excavación de uña | 3d | 2024-02-02 | 2024-02-06 | A7110 SS+3d, A17500 | 217d | 64d | grupo 2 |
|  | 2 | **Rellenos** |  | 2024-02-16 | 2024-04-03 |  |  |  |  |
| A7220 |  | Relleno con material granular | 7d | 2024-02-16 | 2024-02-24 | A7130, A17580 | 127d | 0d | grupo 2 |
| A7225 |  | Relleno con material seleccionado | 7d | 2024-02-16 | 2024-02-24 | A7220 SS, A17585 | 127d | 0d | grupo 2 |
| A7226 |  | Perfilado de talud del dique | 2d | 2024-02-24 | 2024-02-27 | A7225, A17586 | 127d | 0d | grupo 2 |
| A7270 |  | Grava para drenaje | 3d | 2024-02-24 | 2024-02-28 | A7225, A17630 | 201d |  | grupo 2 |
| A7230 |  | Relleno sin compactar | 2d | 2024-04-01 | 2024-04-03 | A7310 | 173d |  | grupo 2 |
| A7240 |  | Relleno afirmado | 2d | 2024-04-01 | 2024-04-03 | A7310, A17600 | 173d |  | grupo 2 |

| ID | WBS | Activity | Duration | Start | Finish | Predecessors | Total float | Free float | Calendar | Filtro |
| --- | --- | --- | --- | --- | --- | --- | --- | --- | --- | --- |
|  | 3 | **Geotextil** |  | 2024-02-27 | 2024-03-02 |  |  |  |  |  |
| A7280 |  | Instalación de Geotextil 400 gr/m2 | 4d | 2024-02-27 | 2024-03-02 | A7290 SS, A17640 | 127d | 9d |  | grupo 2 |
| A7290 |  | Zanja de anclaje | 4d | 2024-02-27 | 2024-03-02 | A7226, A17650 | 127d | 0d |  | grupo 2 |
|  | 4 | **Colocación de Roca** |  | 2024-03-13 | 2024-03-31 |  |  |  |  |  |
| A7300 |  | Colocación de roca en uña | 6d | 2024-03-13 | 2024-03-20 | A7280, A17660 | 118d | 0d |  | grupo 2 |
| A7310 |  | Colocación de roca en talud | 8d | 2024-03-20 | 2024-03-31 | A7300, A17670 | 118d | 0d |  | grupo 2 |
|  | 20 | **DE-PR-49bis-D** |  | 2024-05-04 | 2024-07-14 |  |  |  |  |  |
|  | 1 | **Excavaciones** |  | 2024-05-04 | 2024-05-17 |  |  |  |  |  |
| A15240 |  | Desbroce | 6d | 2024-05-04 | 2024-05-11 | A20290 | 0d |  | 2T - 6x1 - 8 hr - Cañete - paro en avenidas | grupo 2 |
| A15250 |  | Remoción de dique existente | 6d | 2024-05-04 | 2024-05-11 | A15240 SS | 88d | 0d | 2T - 6x1 - 8 hr - Cañete - paro en avenidas | grupo 2 |
| A15260 |  | Excavación de cimentación | 6d | 2024-05-04 | 2024-05-11 | A15250 SS, A20300 | 88d | 0d | 2T - 6x1 - 8 hr - Cañete - paro en avenidas | grupo 2 |
| A15265 |  | Excavación localizada - Sobreexcavación | 6d | 2024-05-04 | 2024-05-11 | A15260 SS | 88d | 0d | 2T - 6x1 - 8 hr - Cañete - paro en avenidas | grupo 2 |
| A15270 |  | Perfilado y conformación de plataforma de fundación | 5d | 2024-05-11 | 2024-05-17 | A15260 SS+6d | 136d |  | 2T - 6x1 - 8 hr - Cañete - paro en avenidas | grupo 2 |
| A15280 |  | Excavación de uña | 5d | 2024-05-11 | 2024-05-17 | A15250 SS+6d | 136d |  | 2T - 6x1 - 8 hr - Cañete - paro en avenidas | grupo 2 |
|  | 2 | **Rellenos** |  | 2024-05-11 | 2024-07-14 |  |  |  |  |  |
| A15360 |  | Relleno con material granular | 16d | 2024-05-11 | 2024-05-30 | A15265 | 88d | 0d | 2T - 6x1 - 8 hr - Cañete - paro en avenidas | grupo 2 |
| A15365 |  | Relleno con material seleccionado | 16d | 2024-05-11 | 2024-05-30 | A15360 SS | 88d | 0d | 2T - 6x1 - 8 hr - Cañete - paro en avenidas | grupo 2 |
| A15366 |  | Perfilado de talud del dique | 11d | 2024-05-18 | 2024-05-31 | A15365 SS+6d | 88d | 0d | 2T - 6x1 - 8 hr - Cañete - paro en avenidas | grupo 2 |
| A15410 |  | Grava para drenaje | 7d | 2024-05-30 | 2024-06-07 | A15365 | 118d |  | 2T - 6x1 - 8 hr - Cañete - paro en avenidas | grupo 2 |
| A15370 |  | Relleno sin compactar | 3d | 2024-07-11 | 2024-07-14 | A15450, A15440 | 88d |  | 2T - 6x1 - 8 hr - Cañete - paro en avenidas | grupo 2 |
| A15380 |  | Relleno afirmado | 2d | 2024-07-11 | 2024-07-13 | A15450 | 89d |  | 2T - 6x1 - 8 hr - Cañete - paro en avenidas | grupo 2 |
|  | 3 | **Geotextil** |  | 2024-06-01 | 2024-06-14 |  |  |  |  |  |
| A15420 |  | Instalación de Geotextil 400 gr/m2 | 10d | 2024-06-01 | 2024-06-14 | A15430 SS | 88d | 0d | 2T - 6x1 - 8 hr - Cañete - paro en avenidas | grupo 2 |
| A15430 |  | Zanja de anclaje | 10d | 2024-06-01 | 2024-06-14 | A15366 SS+12d | 88d | 0d | 2T - 6x1 - 8 hr - Cañete - paro en avenidas | grupo 2 |

| ID | WBS | Activity | Duration | Start | Finish | Predecessors | Total float | Free float | Calendar | Filtro |
| --- | --- | --- | --- | --- | --- | --- | --- | --- | --- | --- |
|  | 4 | **Colocación de Roca** |  | 2024-06-14 | 2024-07-11 |  |  |  |  |  |
| A15440 |  | Colocación de roca en uña | 11d | 2024-06-14 | 2024-06-27 | A15420 | 88d | 0d | 2T - 6x1 - 8 hr - Cañete - paro en avenidas | grupo 2 |
| A15450 |  | Colocación de roca en talud | 16d | 2024-06-21 | 2024-07-11 | A15440 SS+6d | 88d | 0d | 2T - 6x1 - 8 hr - Cañete - paro en avenidas | grupo 2 |
|  | 10 | **DI-PR-40A-D** |  | 2024-05-11 | 2024-09-22 |  |  |  |  |  |
|  | 1 | **Excavaciones** |  | 2024-05-11 | 2024-05-22 |  |  |  |  |  |
| A7840 |  | Desbroce | 5d | 2024-05-11 | 2024-05-17 | A15240 | 0d |  |  | grupo 2 |
| A7850 |  | Remoción de dique existente | 5d | 2024-05-11 | 2024-05-17 | A7840 SS | 0d |  |  | grupo 2 |
| A7860 |  | Excavación de cimentación | 5d | 2024-05-11 | 2024-05-17 | A7850 SS | 0d |  |  | grupo 2 |
| A7865 |  | Excavación localizada - Sobreexcavación | 5d | 2024-05-11 | 2024-05-17 | A7860 SS | 132d | 0d |  | grupo 2 |
| A7880 |  | Excavación de uña | 5d | 2024-05-15 | 2024-05-21 | A7850 SS+3d | 133d |  |  | grupo 2 |
| A7870 |  | Perfilado y conformación de plataforma de fundación | 3d | 2024-05-18 | 2024-05-22 | A7865 SS+6d | 132d |  |  | grupo 2 |
|  | 2 | **Rellenos** |  | 2024-08-14 | 2024-09-22 |  |  |  |  |  |
| A7960 |  | Relleno con material granular | 7d | 2024-08-14 | 2024-08-22 | A19002, A19035 | 25d | 0d |  | grupo 2 |
| A7965 |  | Relleno con material seleccionado | 7d | 2024-08-14 | 2024-08-22 | A7960 SS | 25d | 0d |  | grupo 2 |
| A7966 |  | Perfilado de talud del dique | 2d | 2024-08-22 | 2024-08-24 | A7965 | 25d | 0d |  | grupo 2 |
| A7970 |  | Relleno sin compactar | 2d | 2024-09-20 | 2024-09-22 | A8050, A8040 | 25d |  |  | grupo 2 |
| A7980 |  | Relleno afirmado | 2d | 2024-09-20 | 2024-09-22 | A8050 | 25d |  |  | grupo 2 |
|  | 3 | **Geotextil** |  | 2024-08-24 | 2024-09-01 |  |  |  |  |  |
| A8020 |  | Instalación de Geotextil 400 gr/m2 | 6d | 2024-08-24 | 2024-09-01 | A8030 SS | 25d | 0d |  | grupo 2 |
| A8030 |  | Zanja de anclaje | 6d | 2024-08-24 | 2024-09-01 | A7966 | 25d | 0d |  | grupo 2 |
|  | 4 | **Colocación de Roca** |  | 2024-09-02 | 2024-09-20 |  |  |  |  |  |
| A8040 |  | Colocación de roca en uña | 10d | 2024-09-02 | 2024-09-13 | A8020 SS+6d | 25d | 0d |  | grupo 2 |
| A8050 |  | Colocación de roca en talud | 6d | 2024-09-13 | 2024-09-20 | A8040 | 25d | 0d |  | grupo 2 |
|  | 5 | **Muros** |  | 2024-05-17 | 2024-08-14 |  |  |  |  |  |
|  | 1 | **Cimiento** |  | 2024-05-17 | 2024-06-22 |  |  |  |  |  |
| A18940 |  | Concreto de Nivelacion (f'c=100 kg/cm2) | 5d | 2024-05-17 | 2024-05-23 | A7860 | 0d |  |  | muros |
| A18941 |  | Acero de refuerzo f'y=4200kg/cm2 - cimiento | 17d | 2024-05-23 | 2024-06-13 | A18940 | 0d |  |  | muros |
| A18942 |  | Encofrado y Desencofrado Cara Oculta | 17d | 2024-05-27 | 2024-06-16 | A18941 SS+3d | 0d |  |  | muros |
| A19010 |  | Juntas de dilatación | 17d | 2024-05-27 | 2024-06-16 | A18942 SS | 1d |  |  | muros |
| A18950 |  | Concreto Clase C (f'c=280 kg/cm2) Premezclado - Cimientos reforzados | 19d | 2024-05-30 | 2024-06-22 | A18940, A18942 SS+3d | 0d |  |  | muros |

| ID | WBS | Activity | Duration | Start | Finish | Predecessors | Total float | Free float | Filtro |
| --- | --- | --- | --- | --- | --- | --- | --- | --- | --- |
|  | 2 | **Muro** |  | 2024-06-14 | 2024-08-14 |  |  |  |  |
| A19000 |  | Acero de refuerzo f'y=4200kg/cm2 - muro | 21d | 2024-06-14 | 2024-07-10 | A18950 SS+12d, A18941 | 0d |  | muros |
| A19001 |  | Encofrado y Desencofrado Caravista | 20d | 2024-06-18 | 2024-07-12 | A19000 SS+3d, A18942 | 0d |  | muros |
| A19030 |  | Juntas de dilatación | 20d | 2024-06-18 | 2024-07-12 | A19001 SS, A19010 | 0d |  | muros |
| A19002 |  | Concreto Clase C (f'c=280 kg/cm2) Premezclado - Muros de contencion | 26d | 2024-06-22 | 2024-07-24 | A19001 SS+3d, A18950 | 0d |  | muros |
| A19035 |  | Pintura bituminosa | 16d | 2024-07-24 | 2024-08-14 | A19002, A19030 | 25d | 0d | muros |
|  | 11 | **DI-PR-40B-D** |  | 2024-05-17 | 2024-10-23 |  |  |  |  |
|  | 1 | **Excavaciones** |  | 2024-05-17 | 2024-05-19 |  |  |  |  |
| A8580 |  | Desbroce | 2d | 2024-05-17 | 2024-05-19 | A7840 | 44d | 0d | grupo 2 |
| A8600 |  | Excavación de cimentación | 2d | 2024-05-17 | 2024-05-19 | A8580 SS | 44d |  | grupo 2 |
|  | 2 | **Rellenos** |  | 2024-09-19 | 2024-10-23 |  |  |  |  |
| A8700 |  | Relleno con material granular | 26d | 2024-09-19 | 2024-10-20 | A19102, A19135 | 0d |  | grupo 2 |
| A8705 |  | Relleno con material seleccionado | 26d | 2024-09-19 | 2024-10-20 | A8700 SS | 0d |  | grupo 2 |
| A8710 |  | Relleno sin compactar | 2d | 2024-10-21 | 2024-10-23 | A8705 | 0d |  | grupo 2 |
| A8720 |  | Relleno afirmado | 2d | 2024-10-21 | 2024-10-23 | A8705 | 0d |  | grupo 2 |
|  | 4 | **Colocación de Roca** |  | 2024-09-26 | 2024-10-10 |  |  |  |  |
| A8810 |  | Protección de Talud con Colchón Reno 6m largo x e= 0.30cm | 11d | 2024-09-26 | 2024-10-10 | A8705 SS+6d | 17d | 0d | grupo 2 |
| A8820 |  | Malla Gavión de 1m x 1m x 5m | 11d | 2024-09-26 | 2024-10-10 | A8810 SS | 17d |  | grupo 2 |
|  | 5 | **Muros** |  | 2024-07-12 | 2024-09-19 |  |  |  |  |
|  | 1 | **Cimiento** |  | 2024-07-12 | 2024-08-11 |  |  |  |  |
| A19040 |  | Concreto de Nivelacion (f'c=100 kg/cm2) | 6d | 2024-07-12 | 2024-07-19 | A8600, A19030 | 0d |  | muros |
| A19041 |  | Acero de refuerzo f'y=4200kg/cm2 - cimiento | 11d | 2024-07-19 | 2024-08-02 | A19040 | 0d |  | muros |
| A19042 |  | Encofrado y Desencofrado Cara Oculta | 13d | 2024-07-23 | 2024-08-09 | A19041 SS+3d | 0d |  | muros |
| A19110 |  | Juntas de dilatación | 13d | 2024-07-23 | 2024-08-09 | A19042 SS | 5d |  | muros |
| A19050 |  | Concreto Clase C (f'c=280 kg/cm2) Premezclado - Cimientos reforzados | 12d | 2024-07-26 | 2024-08-11 | A19002 FS+2d, A19042 SS+3d | 0d |  | muros |

| ID | WBS | Activity | Duration | Start | Finish | Predecessors | Total float | Free float | Calendar | Filtro |
| --- | --- | --- | --- | --- | --- | --- | --- | --- | --- | --- |
|  | 2 | **Muro** |  | 2024-08-12 | 2024-09-19 |  |  |  |  |  |
| A19100 |  | Acero de refuerzo f'y=4200kg/cm2 - muro | 13d | 2024-08-12 | 2024-08-27 | A19050 SS+12d, A19041 | 0d |  |  | muros |
| A19101 |  | Encofrado y Desencofrado Caravista | 19d | 2024-08-15 | 2024-09-07 | A19100 SS+3d, A19042 | 0d |  |  | muros |
| A19130 |  | Juntas de dilatación | 19d | 2024-08-15 | 2024-09-07 | A19101 SS, A19110 | 0d |  |  | muros |
| A19102 |  | Concreto Clase C (f'c=280 kg/cm2) Premezclado - Muros de contencion | 17d | 2024-08-19 | 2024-09-08 | A19101 SS+3d, A19050 | 4d |  |  | muros |
| A19135 |  | Pintura bituminosa | 10d | 2024-09-07 | 2024-09-19 | A19102 SS+12d, A19130 | 0d |  |  | muros |
|  | 19 | **DE-PR-47bis-D** |  | 2024-05-20 | 2024-07-17 |  |  |  |  |  |
|  | 1 | **Excavaciones** |  | 2024-05-20 | 2024-05-30 |  |  |  |  |  |
| A14500 |  | Desbroce | 7d | 2024-05-20 | 2024-05-28 | A8580 | 80d | 0d | 2T - 6x1 - 8 hr - Cañete - paro en avenidas | grupo 2 |
| A14510 |  | Remoción de dique existente | 7d | 2024-05-20 | 2024-05-28 | A14500 SS | 80d | 0d | 2T - 6x1 - 8 hr - Cañete - paro en avenidas | grupo 2 |
| A14520 |  | Excavación de cimentación | 7d | 2024-05-20 | 2024-05-28 | A14510 SS | 80d | 0d | 2T - 6x1 - 8 hr - Cañete - paro en avenidas | grupo 2 |
| A14525 |  | Excavación localizada - Sobreexcavación | 7d | 2024-05-20 | 2024-05-28 | A14520 SS | 80d | 0d | 2T - 6x1 - 8 hr - Cañete - paro en avenidas | grupo 2 |
| A14540 |  | Excavación de uña | 4d | 2024-05-23 | 2024-05-28 | A14510 SS+3d | 104d |  | 2T - 6x1 - 8 hr - Cañete - paro en avenidas | grupo 2 |
| A14530 |  | Perfilado y conformación de plataforma de fundación | 3d | 2024-05-27 | 2024-05-30 | A14525 SS+6d | 80d | 0d | 2T - 6x1 - 8 hr - Cañete - paro en avenidas | grupo 2 |
|  | 2 | **Rellenos** |  | 2024-05-30 | 2024-07-17 |  |  |  |  |  |
| A14620 |  | Relleno con material granular | 13d | 2024-05-30 | 2024-06-15 | A14530 | 80d | 0d | 2T - 6x1 - 8 hr - Cañete - paro en avenidas | grupo 2 |
| A14625 |  | Relleno con material seleccionado | 13d | 2024-05-30 | 2024-06-15 | A14620 SS | 80d | 0d | 2T - 6x1 - 8 hr - Cañete - paro en avenidas | grupo 2 |
| A14626 |  | Perfilado de talud del dique | 8d | 2024-06-06 | 2024-06-16 | A14625 SS+6d | 80d | 0d | 2T - 6x1 - 8 hr - Cañete - paro en avenidas | grupo 2 |
| A14670 |  | Grava para drenaje | 3d | 2024-06-15 | 2024-06-19 | A14625 | 103d |  | 2T - 6x1 - 8 hr - Cañete - paro en avenidas | grupo 2 |
| A14630 |  | Relleno sin compactar | 2d | 2024-07-15 | 2024-07-17 | A14710, A14700 | 80d |  | 2T - 6x1 - 8 hr - Cañete - paro en avenidas | grupo 2 |
| A14640 |  | Relleno afirmado | 2d | 2024-07-15 | 2024-07-17 | A14710 | 80d |  | 2T - 6x1 - 8 hr - Cañete - paro en avenidas | grupo 2 |
|  | 3 | **Geotextil** |  | 2024-06-17 | 2024-06-23 |  |  |  |  |  |
| A14680 |  | Instalación de Geotextil 400 gr/m2 | 6d | 2024-06-17 | 2024-06-23 | A14690 SS | 80d | 0d | 2T - 6x1 - 8 hr - Cañete - paro en avenidas | grupo 2 |
| A14690 |  | Zanja de anclaje | 6d | 2024-06-17 | 2024-06-23 | A14626 | 80d | 0d | 2T - 6x1 - 8 hr - Cañete - paro en avenidas | grupo 2 |

| ID | WBS | Activity | Duration | Start | Finish | Predecessors | Total float | Free float | Calendar | Filtro |
| --- | --- | --- | --- | --- | --- | --- | --- | --- | --- | --- |
|  | 4 | **Colocación de Roca** |  | 2024-06-24 | 2024-07-14 |  |  |  |  |  |
| A14700 |  | Colocación de roca en uña | 8d | 2024-06-24 | 2024-07-04 | A14680 | 80d | 0d | 2T - 6x1 - 8 hr - Cañete - paro en avenidas | grupo 2 |
| A14710 |  | Colocación de roca en talud | 11d | 2024-07-02 | 2024-07-14 | A14700 SS+6d | 80d | 0d | 2T - 6x1 - 8 hr - Cañete - paro en avenidas | grupo 2 |
|  | 13 | **Obras Civiles (Interferencias)** |  | 2023-11-17 | 2024-08-30 |  |  |  |  |  |
| A5890 |  | Obras Civiles | 236d | 2023-11-17 | 2024-08-30 | A5620 SS+3d | 44d |  |  | grupo 1 |
|  | 5 | **Infraestructura verde y paisajismo** |  | 2024-05-09 | 2024-10-17 |  |  |  |  |  |
|  | 1 | **Vivero Forestal** |  | 2024-05-09 | 2024-06-07 |  |  |  |  |  |
| A20010 |  | Implementación de vivero temporal | 25d | 2024-05-09 | 2024-06-07 | A4320 | 5d | 0d |  |  |
|  | 2 | **Revegetación / Reforestación de la ribera** |  | 2024-05-27 | 2024-10-17 |  |  |  |  |  |
| A19870 |  | Preparación del Terreno | 104d | 2024-05-27 | 2024-10-01 | A4350 | 9d | 4d |  |  |
| A19880 |  | Plantación de Especies arbustivas y arbóreas | 104d | 2024-06-08 | 2024-10-13 | A19870 SS+6d, A20010 | 5d | 0d |  |  |
| A19890 |  | Riego con camión cisterna (03 meses) | 78d | 2024-07-13 | 2024-10-17 | A19880 FF+3d | 5d |  |  |  |
|  | 3 | **Espacio público próximo a bocatoma fortaleza** |  | 2024-05-27 | 2024-10-01 |  |  |  |  |  |
| A20020 |  | Preparación del espacio público (incl. elemntos estructurales, pasarela y mobiliario) | 104d | 2024-05-27 | 2024-10-01 | A4350 | 18d |  |  |  |
|  | 6 | **Medio Ambiente** |  | 2023-10-02 | 2024-05-30 |  |  |  |  |  |
| A18930 |  | Rescate camarón | 200d | 2023-10-02 | 2024-05-30 | A1000 | 0d |  |  |  |
|  | 7 | **Otros** |  | 2023-11-02 | 2023-12-02 |  |  |  |  |  |
| A19540 |  | Calibración de estación hidrométrica | 26d | 2023-11-02 | 2023-12-02 | A1020 | 273d |  |  |  |
| A19550 |  | Retiro y reubicación de postes de canotaje | 26d | 2023-11-02 | 2023-12-02 | A1020 | 273d |  |  |  |
